# AdV_SAT_ELE_23122010

Schedule from MS Project, 2010-03-01 to 2014-03-03, costs in €, A marks actual dates.
INFN Pisa

## Calendars

- Standard: Mon-Fri 09:00-13:00, 14:00-18:00; Sat-Sun off. Exceptions (off unless hours are given): 2010-08-01.

## Resources

| Resource | Group |
| --- | --- |
| Alberto Gennai | INFN Pisa |
| Diego Passuello | INFN Pisa |
| Carlo Magazzu | INFN Pisa |
| Massimiliano Bitossi | INFN Pisa |
| Giulio Ballardin | EGO |
| TBH_CtrlEng | INFN Pisa |
| TBH_HwEng | INFN Pisa |
| UnspecEGO | EGO |
| UnspecTNPD | INFN TnPd |
| TechSupport | INFN Pisa |
| PCBManufacturing | Costs |
| Assembly | Costs |
| Components | Material |
| Valerio Boschi | INFN Pisa |
| Generic | Material |
| PCBFirm | ExtFirm |
| AssemblyFirm | ExtFirm |
| EGO Laboratory |  |

## Schedule

| ID | WBS | Task | Type | Duration | Start | Finish | Predecessors | Complete | Remaining | Baseline start | Baseline finish | Baseline duration | Total slack | Free slack | Constraint | Resources | Work | Actual work | Cost | Baseline cost |
| --- | --- | --- | --- | --- | --- | --- | --- | --- | --- | --- | --- | --- | --- | --- | --- | --- | --- | --- | --- | --- |
| 1 | 3 | **Suspension Control System** |  | 1005d? | 2010-03-01 A | 2014-01-03 |  | 3% | 972d? | 2010-03-01 | 2013-03-29 | 805d? | 40d |  |  |  | 21672h | 1392h | 275,500 | 910,500 |
| 2 | 3.1 | Scientific & Technical Supervision |  | 36mo? | 2010-03-01 | 2012-11-30 |  |  |  | 2010-03-01 | 2012-11-30 | 36mo? | 325d |  |  |  |  |  |  |  |
| 3 | 3.2 | Contracts & Procurement |  | 36mo? | 2010-03-01 | 2012-11-30 |  |  |  | 2010-03-01 | 2012-11-30 | 36mo? | 325d |  |  |  |  |  |  |  |
| 4 | 3.3 | Front End Crates |  | 6mo? | 2011-01-03 | 2011-06-17 |  |  |  | 2011-01-03 | 2011-06-17 | 6mo? | 585d | 0d | start no earlier than 2011-01-01 | UnspecEGO; Generic [1.4%] | 960h |  | 130,000 | 130,000 |
| 5 | 3.4 | Thermal Stab. System |  | 6mo? | 2011-06-20 | 2011-12-02 | 4 |  |  | 2011-06-20 | 2011-12-02 | 6mo? | 585d |  |  | UnspecEGO; Generic [0.4%] | 960h |  | 35,000 | 35,000 |
| 6 | 3.5 | Motor Control |  | 6mo? | 2011-01-03 | 2011-06-17 |  |  |  | 2011-01-03 | 2011-06-17 | 6mo? | 585d | 0d | start no earlier than 2011-01-01 | UnspecTNPD; Generic [0.1%] | 960h |  | 12,000 | 12,000 |
| 7 | 3.6 | Motor Power |  | 6mo? | 2011-06-20 | 2011-12-02 | 6 |  |  | 2011-06-20 | 2011-12-02 | 6mo? | 585d |  |  | UnspecTNPD; Generic [0.1%] | 960h |  | 12,000 | 12,000 |
| 8 | 3.7 | **LVDT Conditioning** |  | 255d | 2010-12-06 | 2011-11-25 |  |  |  | 2010-03-01 | 2011-05-06 | 310d | 40d |  |  |  | 1080h |  |  | 89,000 |
| 9 | 3.7.1 | Requirement Analysis |  | 2w | 2010-12-06 | 2010-12-17 |  |  |  | 2010-03-01 | 2010-03-12 | 2w | 40d | 0d | start no earlier than 2010-12-06 | TBH_CtrlEng | 80h |  |  |  |
| 10 | 3.7.2 | Requirement Review | milestone | 0d | 2010-12-24 | 2010-12-24 | 9FS+1w |  |  | 2010-03-19 | 2010-03-19 | 0d | 40d | 0d |  |  |  |  |  |  |
| 11 | 3.7.3 | **Prototype** |  | 115d | 2011-01-03 | 2011-06-10 |  |  |  | 2010-03-29 | 2010-09-03 | 115d | 40d |  |  |  | 600h |  |  | 15,000 |
| 12 | 3.7.3.1 | Schematic Design |  | 2w | 2011-01-03 | 2011-01-14 | 10FS+1w |  |  | 2010-03-29 | 2010-04-09 | 2w | 40d | 0d |  | Alberto Gennai | 80h |  |  |  |
| 13 | 3.7.3.2 | Architectural Design Review | milestone | 0d | 2011-01-21 | 2011-01-21 | 12FS+1w |  |  | 2010-04-16 | 2010-04-16 | 0d | 40d | 0d |  |  |  |  |  |  |
| 14 | 3.7.3.3 | PCB Design |  | 4w | 2011-01-31 | 2011-02-25 | 13FS+1w |  |  | 2010-04-26 | 2010-05-21 | 4w | 40d | 0d |  | Alberto Gennai | 160h |  |  |  |
| 15 | 3.7.3.4 | Design Review | milestone | 0d | 2011-03-04 | 2011-03-04 | 14FS+1w |  |  | 2010-05-28 | 2010-05-28 | 0d | 40d | 0d |  |  |  |  |  |  |
| 16 | 3.7.3.5 | Components Purchase Req | milestone | 0d | 2011-03-11 | 2011-03-11 | 15FS+1w |  |  | 2010-06-04 | 2010-06-04 | 0d | 40d | 0d |  | Components |  |  |  | 12,000 |
| 17 | 3.7.3.6 | Components Procurement |  | 4w | 2011-03-14 | 2011-04-08 | 16 |  |  | 2010-06-07 | 2010-07-02 | 4w | 40d | 0d |  |  |  |  |  |  |
| 18 | 3.7.3.7 | Manufacturing Purchase Req. | milestone | 0d | 2011-03-11 | 2011-03-11 | 15FS+1w |  |  | 2010-06-04 | 2010-06-04 | 0d | 40d | 0d |  | PCBManufacturing |  |  |  | 2,000 |
| 19 | 3.7.3.8 | Manufacturing |  | 3w | 2011-03-21 | 2011-04-08 | 18FS+1w |  |  | 2010-06-14 | 2010-07-02 | 3w | 40d | 0d |  | PCBFirm | 120h |  |  |  |
| 20 | 3.7.3.9 | Assembly Purchase Req. | milestone | 0d | 2011-03-11 | 2011-03-11 | 15FS+1w |  |  | 2010-06-04 | 2010-06-04 | 0d | 60d | 20d |  | Assembly |  |  |  | 1,000 |
| 21 | 3.7.3.10 | Assembly |  | 3w | 2011-04-11 | 2011-04-29 | 17, 19, 20 |  |  | 2010-07-05 | 2010-07-23 | 3w | 40d | 0d |  | AssemblyFirm | 120h |  |  |  |
| 22 | 3.7.3.11 | Firmware |  | 2w | 2011-05-09 | 2011-05-20 | 21FS+1w |  |  | 2010-08-02 | 2010-08-13 | 2w | 40d | 0d |  | TBH_CtrlEng | 80h |  |  |  |
| 23 | 3.7.3.12 | Test |  | 1w | 2011-05-30 | 2011-06-03 | 22FS+1w |  |  | 2010-08-23 | 2010-08-27 | 1w | 40d | 0d |  | TBH_CtrlEng | 40h |  |  |  |
| 24 | 3.7.3.13 | Acceptance Test | milestone | 0d | 2011-06-10 | 2011-06-10 | 23FS+1w |  |  | 2010-09-03 | 2010-09-03 | 0d | 40d | 0d |  |  |  |  |  |  |

| ID | WBS | Task | Type | Duration | Start | Finish | Predecessors | Baseline start | Baseline finish | Baseline duration | Total slack | Free slack | Resources | Work | Baseline cost |
| --- | --- | --- | --- | --- | --- | --- | --- | --- | --- | --- | --- | --- | --- | --- | --- |
| 25 | 3.7.4 | **Production** |  | 85d | 2011-08-01 | 2011-11-25 | 170 | 2011-01-10 | 2011-05-06 | 85d | 590d |  |  | 400h | 74,000 |
| 26 | 3.7.4.1 | Schematic Design |  | 1w | 2011-08-01 | 2011-08-05 | 24FS+1w | 2011-01-10 | 2011-01-14 | 1w | 590d | 0d | Alberto Gennai | 40h |  |
| 27 | 3.7.4.2 | PCB Design |  | 2w | 2011-08-15 | 2011-08-26 | 26FS+1w | 2011-01-24 | 2011-02-04 | 2w | 590d | 0d | Alberto Gennai | 80h |  |
| 28 | 3.7.4.3 | Final Design Review | milestone | 0d | 2011-09-02 | 2011-09-02 | 27FS+1w | 2011-02-11 | 2011-02-11 | 0d | 590d | 0d |  |  |  |
| 29 | 3.7.4.4 | Components Purchase Req | milestone | 0d | 2011-09-09 | 2011-09-09 | 28FS+1w | 2011-02-18 | 2011-02-18 | 0d | 600d | 0d | Components |  | 60,000 |
| 30 | 3.7.4.5 | Componentes Procurement |  | 2w | 2011-09-12 | 2011-09-23 | 29 | 2011-02-21 | 2011-03-04 | 2w | 600d | 10d |  |  |  |
| 31 | 3.7.4.6 | Manufacturing Purchase Req | milestone | 0d | 2011-09-09 | 2011-09-09 | 28FS+1w | 2011-02-18 | 2011-02-18 | 0d | 590d | 0d | PCBManufacturing |  | 8,000 |
| 32 | 3.7.4.7 | Manufacturing |  | 3w | 2011-09-19 | 2011-10-07 | 31FS+1w | 2011-02-28 | 2011-03-18 | 3w | 590d | 0d | PCBFirm | 120h |  |
| 33 | 3.7.4.8 | Assembly Purchase Req. | milestone | 0d | 2011-09-09 | 2011-09-09 | 28FS+1w | 2011-02-18 | 2011-02-18 | 0d | 615d | 25d | Assembly |  | 6,000 |
| 34 | 3.7.4.9 | Assembly |  | 2w | 2011-10-17 | 2011-10-28 | 30FS+1w, 32FS+1w, 33 | 2011-03-28 | 2011-04-08 | 2w | 590d | 0d | AssemblyFirm | 80h |  |
| 35 | 3.7.4.10 | Firmware |  | 1w | 2011-11-07 | 2011-11-11 | 34FS+1w | 2011-04-18 | 2011-04-22 | 1w | 590d | 0d | TBH_CtrlEng | 40h |  |
| 36 | 3.7.4.11 | Test |  | 1w | 2011-11-21 | 2011-11-25 | 35FS+1w | 2011-05-02 | 2011-05-06 | 1w | 590d |  | TBH_CtrlEng | 40h |  |
| 37 | 3.8 | **Accelerometers Conditioning** |  | 225d | 2011-06-27 | 2012-05-04 |  | 2010-09-20 | 2011-07-29 | 225d | 40d |  |  | 1080h | 40,000 |
| 38 | 3.8.1 | Requirement Analysis |  | 2w | 2011-06-27 | 2011-07-08 | 15FS+1mo, 24FS+2w | 2010-09-20 | 2010-10-01 | 2w | 40d | 0d | TBH_CtrlEng | 80h |  |
| 39 | 3.8.2 | Requirement Review | milestone | 0d | 2011-07-15 | 2011-07-15 | 38FS+1w | 2010-10-08 | 2010-10-08 | 0d | 40d | 0d |  |  |  |
| 40 | 3.8.3 | **Prototype** |  | 115d | 2011-07-25 | 2011-12-30 |  | 2010-10-18 | 2011-03-25 | 115d | 40d |  |  | 600h | 8,000 |
| 41 | 3.8.3.1 | Schematic Design |  | 2w | 2011-07-25 | 2011-08-05 | 39FS+1w | 2010-10-18 | 2010-10-29 | 2w | 40d | 0d | Alberto Gennai | 80h |  |
| 42 | 3.8.3.2 | Architectural Design Review | milestone | 0d | 2011-08-12 | 2011-08-12 | 41FS+1w | 2010-11-05 | 2010-11-05 | 0d | 40d | 0d |  |  |  |
| 43 | 3.8.3.3 | PCB Design |  | 4w | 2011-08-22 | 2011-09-16 | 42FS+1w | 2010-11-15 | 2010-12-10 | 4w | 40d | 0d | Carlo Magazzu | 160h |  |
| 44 | 3.8.3.4 | Design Review | milestone | 0d | 2011-09-23 | 2011-09-23 | 43FS+1w | 2010-12-17 | 2010-12-17 | 0d | 40d | 0d |  |  |  |
| 45 | 3.8.3.5 | Components Purchase Req | milestone | 0d | 2011-09-30 | 2011-09-30 | 44FS+1w | 2010-12-24 | 2010-12-24 | 0d | 40d | 0d | Components |  | 5,000 |
| 46 | 3.8.3.6 | Components Procurement |  | 4w | 2011-10-03 | 2011-10-28 | 45 | 2010-12-27 | 2011-01-21 | 4w | 40d | 0d |  |  |  |
| 47 | 3.8.3.7 | Manufacturing Purchase Req. | milestone | 0d | 2011-09-30 | 2011-09-30 | 44FS+1w | 2010-12-24 | 2010-12-24 | 0d | 40d | 0d | PCBManufacturing |  | 2,000 |
| 48 | 3.8.3.8 | Manufacturing |  | 3w | 2011-10-10 | 2011-10-28 | 47FS+1w | 2011-01-03 | 2011-01-21 | 3w | 40d | 0d | PCBFirm | 120h |  |
| 49 | 3.8.3.9 | Assembly Purchase Req. | milestone | 0d | 2011-09-30 | 2011-09-30 | 44FS+1w | 2010-12-24 | 2010-12-24 | 0d | 60d | 20d | Assembly |  | 1,000 |
| 50 | 3.8.3.10 | Assembly |  | 3w | 2011-10-31 | 2011-11-18 | 46, 48, 49 | 2011-01-24 | 2011-02-11 | 3w | 40d | 0d | AssemblyFirm | 120h |  |
| 51 | 3.8.3.11 | Firmware |  | 2w | 2011-11-28 | 2011-12-09 | 50FS+1w | 2011-02-21 | 2011-03-04 | 2w | 40d | 0d | TBH_CtrlEng | 80h |  |
| 52 | 3.8.3.12 | Test |  | 1w | 2011-12-19 | 2011-12-23 | 51FS+1w | 2011-03-14 | 2011-03-18 | 1w | 40d | 0d | TBH_CtrlEng | 40h |  |
| 53 | 3.8.3.13 | Acceptance Test | milestone | 0d | 2011-12-30 | 2011-12-30 | 52FS+1w | 2011-03-25 | 2011-03-25 | 0d | 40d | 0d |  |  |  |

| ID | WBS | Task | Type | Duration | Start | Finish | Predecessors | Baseline start | Baseline finish | Baseline duration | Total slack | Free slack | Resources | Work | Baseline cost |
| --- | --- | --- | --- | --- | --- | --- | --- | --- | --- | --- | --- | --- | --- | --- | --- |
| 54 | 3.8.4 | **Production** |  | 85d | 2012-01-09 | 2012-05-04 | 170 | 2011-04-04 | 2011-07-29 | 85d | 130d | 75d |  | 400h | 32,000 |
| 55 | 3.8.4.1 | Schematic Design |  | 1w | 2012-01-09 | 2012-01-13 | 53FS+1w | 2011-04-04 | 2011-04-08 | 1w | 130d | 0d | Carlo Magazzu | 40h |  |
| 56 | 3.8.4.2 | PCB Design |  | 2w | 2012-01-23 | 2012-02-03 | 55FS+1w | 2011-04-18 | 2011-04-29 | 2w | 130d | 0d | Carlo Magazzu | 80h |  |
| 57 | 3.8.4.3 | Final Design Review | milestone | 0d | 2012-02-10 | 2012-02-10 | 56FS+1w | 2011-05-06 | 2011-05-06 | 0d | 130d | 0d |  |  |  |
| 58 | 3.8.4.4 | Components Purchase Req | milestone | 0d | 2012-02-17 | 2012-02-17 | 57FS+1w | 2011-05-13 | 2011-05-13 | 0d | 140d | 0d | Components |  | 25,000 |
| 59 | 3.8.4.5 | Componentes Procurement |  | 2w | 2012-02-20 | 2012-03-02 | 58 | 2011-05-16 | 2011-05-27 | 2w | 140d | 10d |  |  |  |
| 60 | 3.8.4.6 | Manufacturing Purchase Req | milestone | 0d | 2012-02-17 | 2012-02-17 | 57FS+1w | 2011-05-13 | 2011-05-13 | 0d | 130d | 0d | PCBManufacturing |  | 4,000 |
| 61 | 3.8.4.7 | Manufacturing |  | 3w | 2012-02-27 | 2012-03-16 | 60FS+1w | 2011-05-23 | 2011-06-10 | 3w | 130d | 0d | PCBFirm | 120h |  |
| 62 | 3.8.4.8 | Assembly Purchase Req. | milestone | 0d | 2012-02-17 | 2012-02-17 | 57FS+1w | 2011-05-13 | 2011-05-13 | 0d | 155d | 25d | Assembly |  | 3,000 |
| 63 | 3.8.4.9 | Assembly |  | 2w | 2012-03-26 | 2012-04-06 | 59FS+1w, 61FS+1w, 62 | 2011-06-20 | 2011-07-01 | 2w | 130d | 0d | AssemblyFirm | 80h |  |
| 64 | 3.8.4.10 | Firmware |  | 1w | 2012-04-16 | 2012-04-20 | 63FS+1w | 2011-07-11 | 2011-07-15 | 1w | 130d | 0d | TBH_CtrlEng | 40h |  |
| 65 | 3.8.4.11 | Test |  | 1w | 2012-04-30 | 2012-05-04 | 64FS+1w | 2011-07-25 | 2011-07-29 | 1w | 130d |  | TBH_CtrlEng | 40h |  |
| 66 | 3.14 | **DSP Mezzanine** |  | 245d | 2012-01-16 | 2012-12-21 |  | 2011-04-11 | 2012-03-16 | 245d | 40d |  |  | 1240h | 33,000 |
| 67 | 3.14.1 | Requirement Analysis |  | 2w | 2012-01-16 | 2012-01-27 | 53FS+2w | 2011-04-11 | 2011-04-22 | 2w | 40d | 0d | Alberto Gennai | 80h |  |
| 68 | 3.14.2 | Requirement Review | milestone | 0d | 2012-02-03 | 2012-02-03 | 67FS+1w | 2011-04-29 | 2011-04-29 | 0d | 40d | 0d |  |  |  |
| 69 | 3.14.3 | **Prototype** |  | 130d | 2012-02-13 | 2012-08-10 |  | 2011-05-09 | 2011-11-04 | 130d | 40d |  |  | 720h | 7,500 |
| 70 | 3.14.3.1 | Schematic Design |  | 3w | 2012-02-13 | 2012-03-02 | 68FS+1w | 2011-05-09 | 2011-05-27 | 3w | 40d | 0d | Alberto Gennai | 120h |  |
| 71 | 3.14.3.2 | Architectural Design Review | milestone | 0d | 2012-03-09 | 2012-03-09 | 70FS+1w | 2011-06-03 | 2011-06-03 | 0d | 40d | 0d |  |  |  |
| 72 | 3.14.3.3 | PCB Design |  | 6w | 2012-03-19 | 2012-04-27 | 71FS+1w | 2011-06-13 | 2011-07-22 | 6w | 40d | 0d | Alberto Gennai | 240h |  |
| 73 | 3.14.3.4 | Design Review | milestone | 0d | 2012-05-04 | 2012-05-04 | 72FS+1w | 2011-07-29 | 2011-07-29 | 0d | 40d | 0d |  |  |  |
| 74 | 3.14.3.5 | Components Purchase Req | milestone | 0d | 2012-05-11 | 2012-05-11 | 73FS+1w | 2011-08-05 | 2011-08-05 | 0d | 40d | 0d | Components |  | 3,500 |
| 75 | 3.14.3.6 | Components Procurement |  | 4w | 2012-05-14 | 2012-06-08 | 74 | 2011-08-08 | 2011-09-02 | 4w | 40d | 0d |  |  |  |
| 76 | 3.14.3.7 | Manufacturing Purchase Req. | milestone | 0d | 2012-05-11 | 2012-05-11 | 73FS+1w | 2011-08-05 | 2011-08-05 | 0d | 40d | 0d | PCBManufacturing |  | 2,500 |
| 77 | 3.14.3.8 | Manufacturing |  | 3w | 2012-05-21 | 2012-06-08 | 76FS+1w | 2011-08-15 | 2011-09-02 | 3w | 40d | 0d | PCBFirm | 120h |  |
| 78 | 3.14.3.9 | Assembly Purchase Req. | milestone | 0d | 2012-05-11 | 2012-05-11 | 73FS+1w | 2011-08-05 | 2011-08-05 | 0d | 60d | 20d | Assembly |  | 1,500 |
| 79 | 3.14.3.10 | Assembly |  | 3w | 2012-06-11 | 2012-06-29 | 75, 77, 78 | 2011-09-05 | 2011-09-23 | 3w | 40d | 0d | AssemblyFirm | 120h |  |
| 80 | 3.14.3.11 | Firmware |  | 2w | 2012-07-09 | 2012-07-20 | 79FS+1w | 2011-10-03 | 2011-10-14 | 2w | 40d | 0d | Diego Passuello | 80h |  |
| 81 | 3.14.3.12 | Test |  | 1w | 2012-07-30 | 2012-08-03 | 80FS+1w | 2011-10-24 | 2011-10-28 | 1w | 40d | 0d | Diego Passuello | 40h |  |
| 82 | 3.14.3.13 | Acceptance Test | milestone | 0d | 2012-08-10 | 2012-08-10 | 81FS+1w | 2011-11-04 | 2011-11-04 | 0d | 40d | 0d |  |  |  |

| ID | WBS | Task | Type | Duration | Start | Finish | Predecessors | Baseline start | Baseline finish | Baseline duration | Total slack | Free slack | Resources | Work | Cost | Baseline cost |
| --- | --- | --- | --- | --- | --- | --- | --- | --- | --- | --- | --- | --- | --- | --- | --- | --- |
| 83 | 3.14.4 | **Production** |  | 90d | 2012-08-20 | 2012-12-21 | 54 | 2011-11-14 | 2012-03-16 | 90d | 55d | 0d |  | 440h |  | 25,500 |
| 84 | 3.14.4.1 | Schematic Design |  | 1w | 2012-08-20 | 2012-08-24 | 82FS+1w | 2011-11-14 | 2011-11-18 | 1w | 55d | 0d | Alberto Gennai | 40h |  |  |
| 85 | 3.14.4.2 | PCB Design |  | 3w | 2012-09-03 | 2012-09-21 | 84FS+1w | 2011-11-28 | 2011-12-16 | 3w | 55d | 0d | Alberto Gennai | 120h |  |  |
| 86 | 3.14.4.3 | Final Design Review | milestone | 0d | 2012-09-28 | 2012-09-28 | 85FS+1w | 2011-12-23 | 2011-12-23 | 0d | 55d | 0d |  |  |  |  |
| 87 | 3.14.4.4 | Components Purchase Req | milestone | 0d | 2012-10-05 | 2012-10-05 | 86FS+1w | 2011-12-30 | 2011-12-30 | 0d | 65d | 0d | Components |  |  | 14,000 |
| 88 | 3.14.4.5 | Componentes Procurement |  | 2w | 2012-10-08 | 2012-10-19 | 87 | 2012-01-02 | 2012-01-13 | 2w | 65d | 10d |  |  |  |  |
| 89 | 3.14.4.6 | Manufacturing Purchase Req | milestone | 0d | 2012-10-05 | 2012-10-05 | 86FS+1w | 2011-12-30 | 2011-12-30 | 0d | 55d | 0d | PCBManufacturing |  |  | 8,000 |
| 90 | 3.14.4.7 | Manufacturing |  | 3w | 2012-10-15 | 2012-11-02 | 89FS+1w | 2012-01-09 | 2012-01-27 | 3w | 55d | 0d | PCBFirm | 120h |  |  |
| 91 | 3.14.4.8 | Assembly Purchase Req. | milestone | 0d | 2012-10-05 | 2012-10-05 | 86FS+1w | 2011-12-30 | 2011-12-30 | 0d | 80d | 25d | Assembly |  |  | 3,500 |
| 92 | 3.14.4.9 | Assembly |  | 2w | 2012-11-12 | 2012-11-23 | 88FS+1w, 90FS+1w, 91 | 2012-02-06 | 2012-02-17 | 2w | 55d | 0d | AssemblyFirm | 80h |  |  |
| 93 | 3.14.4.10 | Firmware |  | 1w | 2012-12-03 | 2012-12-07 | 92FS+1w | 2012-02-27 | 2012-03-02 | 1w | 55d | 0d | Diego Passuello | 40h |  |  |
| 94 | 3.14.4.11 | Test |  | 1w | 2012-12-17 | 2012-12-21 | 93FS+1w | 2012-03-12 | 2012-03-16 | 1w | 55d |  | Diego Passuello | 40h |  |  |
| 95 | 3.16 | **DSP Carrrier** |  | 210d | 2012-08-27 | 2013-06-14 |  | 2011-11-21 | 2012-09-07 | 210d | 40d |  |  | 960h | 500 | 12,000 |
| 96 | 3.16.1 | Requirement Analysis |  | 2w | 2012-08-27 | 2012-09-07 | 73FS+1mo, 82FS+2w | 2011-11-21 | 2011-12-02 | 2w | 40d | 0d | Alberto Gennai | 80h |  |  |
| 97 | 3.16.2 | Requirement Review | milestone | 0d | 2012-09-14 | 2012-09-14 | 96FS+1w | 2011-12-09 | 2011-12-09 | 0d | 40d | 0d |  |  |  |  |
| 98 | 3.16.3 | **Prototype** |  | 100d | 2012-09-24 | 2013-02-08 |  | 2011-12-19 | 2012-05-04 | 100d | 40d |  |  | 480h |  | 4,000 |
| 99 | 3.16.3.1 | Schematic Design |  | 1w | 2012-09-24 | 2012-09-28 | 97FS+1w | 2011-12-19 | 2011-12-23 | 1w | 40d | 0d | Carlo Magazzu | 40h |  |  |
| 100 | 3.16.3.2 | Architectural Design Review | milestone | 0d | 2012-10-05 | 2012-10-05 | 99FS+1w | 2011-12-30 | 2011-12-30 | 0d | 40d | 0d |  |  |  |  |
| 101 | 3.16.3.3 | PCB Design |  | 2w | 2012-10-15 | 2012-10-26 | 100FS+1w | 2012-01-09 | 2012-01-20 | 2w | 40d | 0d | Carlo Magazzu | 80h |  |  |
| 102 | 3.16.3.4 | Design Review | milestone | 0d | 2012-11-02 | 2012-11-02 | 101FS+1w | 2012-01-27 | 2012-01-27 | 0d | 40d | 0d |  |  |  |  |
| 103 | 3.16.3.5 | Components Purchase Req | milestone | 0d | 2012-11-09 | 2012-11-09 | 102FS+1w | 2012-02-03 | 2012-02-03 | 0d | 40d | 0d | Components |  |  | 1,000 |
| 104 | 3.16.3.6 | Components Procurement |  | 4w | 2012-11-12 | 2012-12-07 | 103 | 2012-02-06 | 2012-03-02 | 4w | 40d | 0d |  |  |  |  |
| 105 | 3.16.3.7 | Manufacturing Purchase Req. | milestone | 0d | 2012-11-09 | 2012-11-09 | 102FS+1w | 2012-02-03 | 2012-02-03 | 0d | 40d | 0d | PCBManufacturing |  |  | 2,000 |
| 106 | 3.16.3.8 | Manufacturing |  | 3w | 2012-11-19 | 2012-12-07 | 105FS+1w | 2012-02-13 | 2012-03-02 | 3w | 40d | 0d | PCBFirm | 120h |  |  |
| 107 | 3.16.3.9 | Assembly Purchase Req. | milestone | 0d | 2012-11-09 | 2012-11-09 | 102FS+1w | 2012-02-03 | 2012-02-03 | 0d | 60d | 20d | Assembly |  |  | 1,000 |
| 108 | 3.16.3.10 | Assembly |  | 3w | 2012-12-10 | 2012-12-28 | 104, 106, 107 | 2012-03-05 | 2012-03-23 | 3w | 40d | 0d | AssemblyFirm | 120h |  |  |
| 109 | 3.16.3.11 | Firmware |  | 2w | 2013-01-07 | 2013-01-18 | 108FS+1w | 2012-04-02 | 2012-04-13 | 2w | 40d | 0d | Massimiliano Bitossi | 80h |  |  |
| 110 | 3.16.3.12 | Test |  | 1w | 2013-01-28 | 2013-02-01 | 109FS+1w | 2012-04-23 | 2012-04-27 | 1w | 40d | 0d | Massimiliano Bitossi | 40h |  |  |
| 111 | 3.16.3.13 | Acceptance Test | milestone | 0d | 2013-02-08 | 2013-02-08 | 110FS+1w | 2012-05-04 | 2012-05-04 | 0d | 40d | 0d |  |  |  |  |

| ID | WBS | Task | Type | Duration | Start | Finish | Predecessors | Baseline start | Baseline finish | Baseline duration | Total slack | Free slack | Resources | Work | Cost | Baseline cost |
| --- | --- | --- | --- | --- | --- | --- | --- | --- | --- | --- | --- | --- | --- | --- | --- | --- |
| 112 | 3.16.4 | **Production** |  | 85d | 2013-02-18 | 2013-06-14 | 83 | 2012-05-14 | 2012-09-07 | 85d | 185d |  |  | 400h | 500 | 8,000 |
| 113 | 3.16.4.1 | Schematic Design |  | 1w | 2013-02-18 | 2013-02-22 | 111FS+1w | 2012-05-14 | 2012-05-18 | 1w | 185d | 0d | Carlo Magazzu | 40h |  |  |
| 114 | 3.16.4.2 | PCB Design |  | 2w | 2013-03-04 | 2013-03-15 | 113FS+1w | 2012-05-28 | 2012-06-08 | 2w | 185d | 0d | Carlo Magazzu | 80h |  |  |
| 115 | 3.16.4.3 | Final Design Review | milestone | 0d | 2013-03-22 | 2013-03-22 | 114FS+1w | 2012-06-15 | 2012-06-15 | 0d | 185d | 0d |  |  |  |  |
| 116 | 3.16.4.4 | Components Purchase Req | milestone | 0d | 2013-03-29 | 2013-03-29 | 115FS+1w | 2012-06-22 | 2012-06-22 | 0d | 195d | 0d | Components |  | 500 | 4,000 |
| 117 | 3.16.4.5 | Componentes Procurement |  | 2w | 2013-04-01 | 2013-04-12 | 116 | 2012-06-25 | 2012-07-06 | 2w | 195d | 10d |  |  |  |  |
| 118 | 3.16.4.6 | Manufacturing Purchase Req | milestone | 0d | 2013-03-29 | 2013-03-29 | 115FS+1w | 2012-06-22 | 2012-06-22 | 0d | 185d | 0d | PCBManufacturing |  |  | 2,000 |
| 119 | 3.16.4.7 | Manufacturing |  | 3w | 2013-04-08 | 2013-04-26 | 118FS+1w | 2012-07-02 | 2012-07-20 | 3w | 185d | 0d | PCBFirm | 120h |  |  |
| 120 | 3.16.4.8 | Assembly Purchase Req. | milestone | 0d | 2013-03-29 | 2013-03-29 | 115FS+1w | 2012-06-22 | 2012-06-22 | 0d | 210d | 25d | Assembly |  |  | 2,000 |
| 121 | 3.16.4.9 | Assembly |  | 2w | 2013-05-06 | 2013-05-17 | 117FS+1w, 119FS+1w, 120 | 2012-07-30 | 2012-08-10 | 2w | 185d | 0d | AssemblyFirm | 80h |  |  |
| 122 | 3.16.4.10 | Firmware |  | 1w | 2013-05-27 | 2013-05-31 | 121FS+1w | 2012-08-20 | 2012-08-24 | 1w | 185d | 0d | Massimiliano Bitossi | 40h |  |  |
| 123 | 3.16.4.11 | Test |  | 1w | 2013-06-10 | 2013-06-14 | 122FS+1w | 2012-09-03 | 2012-09-07 | 1w | 185d |  | Massimiliano Bitossi | 40h |  |  |
| 124 | 3.15 | **Data Transfer IF** |  | 225d | 2013-02-25 | 2014-01-03 |  | 2012-05-21 | 2013-03-29 | 225d | 40d |  |  | 1080h | -11,000 | 16,500 |
| 125 | 3.15.1 | Requirement Analysis |  | 2w | 2013-02-25 | 2013-03-08 | 111FS+2w | 2012-05-21 | 2012-06-01 | 2w | 40d | 0d | Diego Passuello | 80h |  |  |
| 126 | 3.15.2 | Requirement Review | milestone | 0d | 2013-03-15 | 2013-03-15 | 125FS+1w | 2012-06-08 | 2012-06-08 | 0d | 40d | 0d |  |  |  |  |
| 127 | 3.15.3 | **Prototype** |  | 115d | 2013-03-25 | 2013-08-30 |  | 2012-06-18 | 2012-11-23 | 115d | 40d |  |  | 600h | -2,000 | 4,500 |
| 128 | 3.15.3.1 | Schematic Design |  | 2w | 2013-03-25 | 2013-04-05 | 126FS+1w | 2012-06-18 | 2012-06-29 | 2w | 40d | 0d | Carlo Magazzu | 80h |  |  |
| 129 | 3.15.3.2 | Architectural Design Review | milestone | 0d | 2013-04-12 | 2013-04-12 | 128FS+1w | 2012-07-06 | 2012-07-06 | 0d | 40d | 0d |  |  |  |  |
| 130 | 3.15.3.3 | PCB Design |  | 4w | 2013-04-22 | 2013-05-17 | 129FS+1w | 2012-07-16 | 2012-08-10 | 4w | 40d | 0d | Carlo Magazzu | 160h |  |  |
| 131 | 3.15.3.4 | Design Review | milestone | 0d | 2013-05-24 | 2013-05-24 | 130FS+1w | 2012-08-17 | 2012-08-17 | 0d | 40d | 0d |  |  |  |  |
| 132 | 3.15.3.5 | Components Purchase Req | milestone | 0d | 2013-05-31 | 2013-05-31 | 131FS+1w | 2012-08-24 | 2012-08-24 | 0d | 40d | 0d | Components |  | -2,000 | 1,000 |
| 133 | 3.15.3.6 | Components Procurement |  | 4w | 2013-06-03 | 2013-06-28 | 132 | 2012-08-27 | 2012-09-21 | 4w | 40d | 0d |  |  |  |  |
| 134 | 3.15.3.7 | Manufacturing Purchase Req. | milestone | 0d | 2013-05-31 | 2013-05-31 | 131FS+1w | 2012-08-24 | 2012-08-24 | 0d | 40d | 0d | PCBManufacturing |  |  | 2,000 |
| 135 | 3.15.3.8 | Manufacturing |  | 3w | 2013-06-10 | 2013-06-28 | 134FS+1w | 2012-09-03 | 2012-09-21 | 3w | 40d | 0d | PCBFirm | 120h |  |  |
| 136 | 3.15.3.9 | Assembly Purchase Req. | milestone | 0d | 2013-05-31 | 2013-05-31 | 131FS+1w | 2012-08-24 | 2012-08-24 | 0d | 60d | 20d | Assembly |  |  | 1,500 |
| 137 | 3.15.3.10 | Assembly |  | 3w | 2013-07-01 | 2013-07-19 | 133, 135, 136 | 2012-09-24 | 2012-10-12 | 3w | 40d | 0d | AssemblyFirm | 120h |  |  |
| 138 | 3.15.3.11 | Firmware |  | 2w | 2013-07-29 | 2013-08-09 | 137FS+1w | 2012-10-22 | 2012-11-02 | 2w | 40d | 0d | Diego Passuello | 80h |  |  |
| 139 | 3.15.3.12 | Test |  | 1w | 2013-08-19 | 2013-08-23 | 138FS+1w | 2012-11-12 | 2012-11-16 | 1w | 40d | 0d | Diego Passuello | 40h |  |  |
| 140 | 3.15.3.13 | Acceptance Test | milestone | 0d | 2013-08-30 | 2013-08-30 | 139FS+1w | 2012-11-23 | 2012-11-23 | 0d | 40d | 0d |  |  |  |  |

| ID | WBS | Task | Type | Duration | Start | Finish | Predecessors | Complete | Remaining | Baseline start | Baseline finish | Baseline duration | Total slack | Free slack | Constraint | Resources | Work | Actual work | Cost | Baseline cost |
| --- | --- | --- | --- | --- | --- | --- | --- | --- | --- | --- | --- | --- | --- | --- | --- | --- | --- | --- | --- | --- |
| 141 | 3.15.4 | **Production** |  | 85d | 2013-09-09 | 2014-01-03 | 83 |  |  | 2012-12-03 | 2013-03-29 | 85d | 40d |  |  |  | 400h |  | -9,000 | 12,000 |
| 142 | 3.15.4.1 | Schematic Design |  | 1w | 2013-09-09 | 2013-09-13 | 140FS+1w |  |  | 2012-12-03 | 2012-12-07 | 1w | 40d | 0d |  | Carlo Magazzu | 40h |  |  |  |
| 143 | 3.15.4.2 | PCB Design |  | 2w | 2013-09-23 | 2013-10-04 | 142FS+1w |  |  | 2012-12-17 | 2012-12-28 | 2w | 40d | 0d |  | Carlo Magazzu | 80h |  |  |  |
| 144 | 3.15.4.3 | Final Design Review | milestone | 0d | 2013-10-11 | 2013-10-11 | 143FS+1w |  |  | 2013-01-04 | 2013-01-04 | 0d | 40d | 0d |  |  |  |  |  |  |
| 145 | 3.15.4.4 | Components Purchase Req | milestone | 0d | 2013-10-18 | 2013-10-18 | 144FS+1w |  |  | 2013-01-11 | 2013-01-11 | 0d | 50d | 0d |  | Components |  |  | -6,000 | 6,000 |
| 146 | 3.15.4.5 | Componentes Procurement |  | 2w | 2013-10-21 | 2013-11-01 | 145 |  |  | 2013-01-14 | 2013-01-25 | 2w | 50d | 10d |  |  |  |  |  |  |
| 147 | 3.15.4.6 | Manufacturing Purchase Req | milestone | 0d | 2013-10-18 | 2013-10-18 | 144FS+1w |  |  | 2013-01-11 | 2013-01-11 | 0d | 40d | 0d |  | PCBManufacturing |  |  | -3,000 | 3,000 |
| 148 | 3.15.4.7 | Manufacturing |  | 3w | 2013-10-28 | 2013-11-15 | 147FS+1w |  |  | 2013-01-21 | 2013-02-08 | 3w | 40d | 0d |  | PCBFirm | 120h |  |  |  |
| 149 | 3.15.4.8 | Assembly Purchase Req. | milestone | 0d | 2013-10-18 | 2013-10-18 | 144FS+1w |  |  | 2013-01-11 | 2013-01-11 | 0d | 65d | 25d |  | Assembly |  |  |  | 3,000 |
| 150 | 3.15.4.9 | Assembly |  | 2w | 2013-11-25 | 2013-12-06 | 146FS+1w, 148FS+1w, 149 |  |  | 2013-02-18 | 2013-03-01 | 2w | 40d | 0d |  | AssemblyFirm | 80h |  |  |  |
| 151 | 3.15.4.10 | Firmware |  | 1w | 2013-12-16 | 2013-12-20 | 150FS+1w |  |  | 2013-03-11 | 2013-03-15 | 1w | 40d | 0d |  | Diego Passuello | 40h |  |  |  |
| 152 | 3.15.4.11 | Test |  | 1w | 2013-12-30 | 2014-01-03 | 151FS+1w |  |  | 2013-03-25 | 2013-03-29 | 1w | 40d |  |  | Diego Passuello | 40h |  |  |  |
| 153 | 3.12 | **Data Converter Mezzanine** |  | 370d | 2010-03-01 A | 2011-07-29 |  | 54% | 171.3d | 2010-03-01 | 2011-01-07 | 225d | 675d |  |  |  | 2512h | 1392h | -92,000 | 208,000 |
| 154 | 3.12.1 | Requirement Analysis |  | 2w | 2010-03-01 | 2010-03-12 |  |  |  | 2010-03-01 | 2010-03-12 | 2w | 1030d | 0d |  | TBH_CtrlEng | 80h |  |  |  |
| 155 | 3.12.2 | Requirement Review | milestone | 0d | 2010-03-19 | 2010-03-19 | 154FS+1w |  |  | 2010-03-19 | 2010-03-19 | 0d | 1030d |  |  |  |  |  |  |  |
| 156 | 3.12.3 | **Prototype** |  | 260d | 2010-03-29 A | 2011-03-25 |  | 69% | 81.89d | 2010-03-29 | 2010-09-03 | 115d | 110d |  |  |  | 2032h | 1392h | -2,000 | 28,000 |
| 157 | 3.12.3.1 | Schematic Design |  | 8w | 2010-03-29 A | 2010-05-21 A | 155FS+1w | 100% |  | 2010-03-29 | 2010-04-09 | 2w |  |  |  | Massimiliano Bitossi | 320h | 320h |  |  |
| 158 | 3.12.3.2 | Architectural Design Review | milestone | 0d | 2010-05-24 A | 2010-05-24 A | 157FS+1w | 100% |  | 2010-04-16 | 2010-04-16 | 0d |  |  |  |  |  |  |  |  |
| 159 | 3.12.3.3 | PCB Design |  | 26.8w | 2010-05-25 A | 2010-11-26 A | 158FS+1w | 100% |  | 2010-04-26 | 2010-05-21 | 4w |  |  |  | Massimiliano Bitossi | 1072h | 1072h |  |  |
| 160 | 3.12.3.4 | Design Review | milestone | 0d | 2010-11-29 A | 2010-11-29 A | 159FS+1w | 100% |  | 2010-05-28 | 2010-05-28 | 0d |  |  |  |  |  |  |  |  |
| 161 | 3.12.3.5 | Components Purchase Req | milestone | 0d | 2010-12-03 | 2010-12-03 | 160FS+1w |  |  | 2010-06-04 | 2010-06-04 | 0d | 110d | 0d |  | Components |  |  |  | 20,000 |
| 162 | 3.12.3.6 | Components Procurement |  | 4w | 2010-12-06 | 2010-12-31 | 161 |  |  | 2010-06-07 | 2010-07-02 | 4w | 110d | 0d |  | AssemblyFirm | 160h |  |  |  |
| 163 | 3.12.3.7 | Manufacturing Purchase Req. | milestone | 0d | 2010-12-06 | 2010-12-06 | 160FS+1w |  |  | 2010-06-04 | 2010-06-04 | 0d | 110d | 0d | start no earlier than 2010-12-06 | PCBManufacturing |  |  |  | 5,000 |
| 164 | 3.12.3.8 | Manufacturing |  | 3w | 2010-12-13 | 2010-12-31 | 163FS+1w |  |  | 2010-06-14 | 2010-07-02 | 3w | 110d | 0d |  | PCBFirm | 120h |  |  |  |
| 165 | 3.12.3.9 | Assembly Purchase Req. | milestone | 0d | 2010-12-06 | 2010-12-06 | 160FS+1w |  |  | 2010-06-04 | 2010-06-04 | 0d | 130d | 20d | start no earlier than 2010-12-06 | Assembly |  |  | -2,000 | 3,000 |
| 166 | 3.12.3.10 | Assembly |  | 3w | 2011-01-03 | 2011-01-21 | 162, 164, 165 |  |  | 2010-07-05 | 2010-07-23 | 3w | 110d | 0d |  | AssemblyFirm | 120h |  |  |  |
| 167 | 3.12.3.11 | Firmware |  | 2w | 2011-01-31 | 2011-02-11 | 166FS+1w |  |  | 2010-08-02 | 2010-08-13 | 2w | 110d | 0d |  | Massimiliano Bitossi | 80h |  |  |  |
| 168 | 3.12.3.12 | Test |  | 4w | 2011-02-21 | 2011-03-18 | 167FS+1w |  |  | 2010-08-23 | 2010-08-27 | 1w | 110d | 0d |  | Massimiliano Bitossi | 160h |  |  |  |
| 169 | 3.12.3.13 | Acceptance Test | milestone | 0d | 2011-03-25 | 2011-03-25 | 168FS+1w |  |  | 2010-09-03 | 2010-09-03 | 0d | 110d | 0d |  |  |  |  |  |  |

| ID | WBS | Task | Type | Duration | Start | Finish | Predecessors | Baseline start | Baseline finish | Baseline duration | Total slack | Free slack | Resources | Work | Cost | Baseline cost |
| --- | --- | --- | --- | --- | --- | --- | --- | --- | --- | --- | --- | --- | --- | --- | --- | --- |
| 170 | 3.12.4 | **Production** |  | 85d | 2011-04-04 | 2011-07-29 |  | 2010-09-13 | 2011-01-07 | 85d | 245d | 0d |  | 400h | -90,000 | 180,000 |
| 171 | 3.12.4.1 | Schematic Design |  | 1w | 2011-04-04 | 2011-04-08 | 169FS+1w | 2010-09-13 | 2010-09-17 | 1w | 245d | 0d | Massimiliano Bitossi | 40h |  |  |
| 172 | 3.12.4.2 | PCB Design |  | 2w | 2011-04-18 | 2011-04-29 | 171FS+1w | 2010-09-27 | 2010-10-08 | 2w | 245d | 0d | Massimiliano Bitossi | 80h |  |  |
| 173 | 3.12.4.3 | Final Design Review | milestone | 0d | 2011-05-06 | 2011-05-06 | 172FS+1w | 2010-10-15 | 2010-10-15 | 0d | 245d | 0d |  |  |  |  |
| 174 | 3.12.4.4 | Components Purchase Req | milestone | 0d | 2011-05-13 | 2011-05-13 | 173FS+1w | 2010-10-22 | 2010-10-22 | 0d | 255d | 0d | Components |  | -50,000 | 150,000 |
| 175 | 3.12.4.5 | Componentes Procurement |  | 2w | 2011-05-16 | 2011-05-27 | 174 | 2010-10-25 | 2010-11-05 | 2w | 255d | 10d |  |  |  |  |
| 176 | 3.12.4.6 | Manufacturing Purchase Req | milestone | 0d | 2011-05-13 | 2011-05-13 | 173FS+1w | 2010-10-22 | 2010-10-22 | 0d | 245d | 0d | PCBManufacturing |  | -20,000 | 20,000 |
| 177 | 3.12.4.7 | Manufacturing |  | 3w | 2011-05-23 | 2011-06-10 | 176FS+1w | 2010-11-01 | 2010-11-19 | 3w | 245d | 0d | PCBFirm | 120h |  |  |
| 178 | 3.12.4.8 | Assembly Purchase Req. | milestone | 0d | 2011-05-13 | 2011-05-13 | 173FS+1w | 2010-10-22 | 2010-10-22 | 0d | 270d | 25d | Assembly |  | -20,000 | 10,000 |
| 179 | 3.12.4.9 | Assembly |  | 2w | 2011-06-20 | 2011-07-01 | 175FS+1w, 177FS+1w, 178 | 2010-11-29 | 2010-12-10 | 2w | 245d | 0d | AssemblyFirm | 80h |  |  |
| 180 | 3.12.4.10 | Firmware |  | 1w | 2011-07-11 | 2011-07-15 | 179FS+1w | 2010-12-20 | 2010-12-24 | 1w | 245d | 0d | Massimiliano Bitossi | 40h |  |  |
| 181 | 3.12.4.11 | Test |  | 1w | 2011-07-25 | 2011-07-29 | 180FS+1w | 2011-01-03 | 2011-01-07 | 1w | 245d |  | Massimiliano Bitossi | 40h |  |  |
| 182 | 3.13 | **General Purpose DAC** |  | 530d | 2011-04-11 | 2013-04-19 |  | 2010-09-20 | 2012-07-13 | 475d | 55d |  |  | 880h |  | 17,000 |
| 183 | 3.13.1 | Requirement Analysis |  | 2w | 2011-04-11 | 2011-04-22 | 160FS+1mo, 169FS+2w | 2010-09-20 | 2010-10-01 | 2w | 110d | 0d |  |  |  |  |
| 184 | 3.13.2 | Requirement Review | milestone | 0d | 2011-04-29 | 2011-04-29 | 183FS+1w | 2010-10-08 | 2010-10-08 | 0d | 110d | 0d |  |  |  |  |
| 185 | 3.13.3 | **Prototype** |  | 100d | 2011-05-09 | 2011-09-23 |  | 2010-10-18 | 2011-03-04 | 100d | 110d |  |  | 480h |  | 4,500 |
| 186 | 3.13.3.1 | Schematic Design |  | 1w | 2011-05-09 | 2011-05-13 | 184FS+1w | 2010-10-18 | 2010-10-22 | 1w | 110d | 0d | Massimiliano Bitossi | 40h |  |  |
| 187 | 3.13.3.2 | Architectural Design Review | milestone | 0d | 2011-05-20 | 2011-05-20 | 186FS+1w | 2010-10-29 | 2010-10-29 | 0d | 110d | 0d |  |  |  |  |
| 188 | 3.13.3.3 | PCB Design |  | 2w | 2011-05-30 | 2011-06-10 | 187FS+1w | 2010-11-08 | 2010-11-19 | 2w | 110d | 0d | Massimiliano Bitossi | 80h |  |  |
| 189 | 3.13.3.4 | Design Review | milestone | 0d | 2011-06-17 | 2011-06-17 | 188FS+1w | 2010-11-26 | 2010-11-26 | 0d | 110d | 0d |  |  |  |  |
| 190 | 3.13.3.5 | Components Purchase Req | milestone | 0d | 2011-06-24 | 2011-06-24 | 189FS+1w | 2010-12-03 | 2010-12-03 | 0d | 110d | 0d | Components |  |  | 1,500 |
| 191 | 3.13.3.6 | Components Procurement |  | 4w | 2011-06-27 | 2011-07-22 | 190 | 2010-12-06 | 2010-12-31 | 4w | 110d | 0d |  |  |  |  |
| 192 | 3.13.3.7 | Manufacturing Purchase Req. | milestone | 0d | 2011-06-24 | 2011-06-24 | 189FS+1w | 2010-12-03 | 2010-12-03 | 0d | 110d | 0d | PCBManufacturing |  |  | 2,000 |
| 193 | 3.13.3.8 | Manufacturing |  | 3w | 2011-07-04 | 2011-07-22 | 192FS+1w | 2010-12-13 | 2010-12-31 | 3w | 110d | 0d | PCBFirm | 120h |  |  |
| 194 | 3.13.3.9 | Assembly Purchase Req. | milestone | 0d | 2011-06-24 | 2011-06-24 | 189FS+1w | 2010-12-03 | 2010-12-03 | 0d | 130d | 20d | Assembly |  |  | 1,000 |
| 195 | 3.13.3.10 | Assembly |  | 3w | 2011-07-25 | 2011-08-12 | 191, 193, 194 | 2011-01-03 | 2011-01-21 | 3w | 110d | 0d | AssemblyFirm | 120h |  |  |
| 196 | 3.13.3.11 | Firmware |  | 2w | 2011-08-22 | 2011-09-02 | 195FS+1w | 2011-01-31 | 2011-02-11 | 2w | 110d | 0d | Massimiliano Bitossi | 80h |  |  |
| 197 | 3.13.3.12 | Test |  | 1w | 2011-09-12 | 2011-09-16 | 196FS+1w | 2011-02-21 | 2011-02-25 | 1w | 110d | 0d | Massimiliano Bitossi | 40h |  |  |
| 198 | 3.13.3.13 | Acceptance Test | milestone | 0d | 2011-09-23 | 2011-09-23 | 197FS+1w | 2011-03-04 | 2011-03-04 | 0d | 110d | 0d |  |  |  |  |

| ID | WBS | Task | Type | Duration | Start | Finish | Predecessors | Baseline start | Baseline finish | Baseline duration | Total slack | Free slack | Resources | Work | Cost | Baseline cost |
| --- | --- | --- | --- | --- | --- | --- | --- | --- | --- | --- | --- | --- | --- | --- | --- | --- |
| 199 | 3.13.4 | **Production** |  | 85d | 2012-12-24 | 2013-04-19 | 83 | 2012-03-19 | 2012-07-13 | 85d | 55d | 0d |  | 400h |  | 12,500 |
| 200 | 3.13.4.1 | Schematic Design |  | 1w | 2012-12-24 | 2012-12-28 | 198FS+1w | 2012-03-19 | 2012-03-23 | 1w | 55d | 0d | Massimiliano Bitossi | 40h |  |  |
| 201 | 3.13.4.2 | PCB Design |  | 2w | 2013-01-07 | 2013-01-18 | 200FS+1w | 2012-04-02 | 2012-04-13 | 2w | 55d | 0d | Massimiliano Bitossi | 80h |  |  |
| 202 | 3.13.4.3 | Final Design Review | milestone | 0d | 2013-01-25 | 2013-01-25 | 201FS+1w | 2012-04-20 | 2012-04-20 | 0d | 55d | 0d |  |  |  |  |
| 203 | 3.13.4.4 | Components Purchase Req | milestone | 0d | 2013-02-01 | 2013-02-01 | 202FS+1w | 2012-04-27 | 2012-04-27 | 0d | 65d | 0d | Components |  |  | 7,000 |
| 204 | 3.13.4.5 | Componentes Procurement |  | 2w | 2013-02-04 | 2013-02-15 | 203 | 2012-04-30 | 2012-05-11 | 2w | 65d | 10d |  |  |  |  |
| 205 | 3.13.4.6 | Manufacturing Purchase Req | milestone | 0d | 2013-02-01 | 2013-02-01 | 202FS+1w | 2012-04-27 | 2012-04-27 | 0d | 55d | 0d | PCBManufacturing |  |  | 4,000 |
| 206 | 3.13.4.7 | Manufacturing |  | 3w | 2013-02-11 | 2013-03-01 | 205FS+1w | 2012-05-07 | 2012-05-25 | 3w | 55d | 0d | PCBFirm | 120h |  |  |
| 207 | 3.13.4.8 | Assembly Purchase Req. | milestone | 0d | 2013-02-01 | 2013-02-01 | 202FS+1w | 2012-04-27 | 2012-04-27 | 0d | 80d | 25d | Assembly |  |  | 1,500 |
| 208 | 3.13.4.9 | Assembly |  | 2w | 2013-03-11 | 2013-03-22 | 204FS+1w, 206FS+1w, 207 | 2012-06-04 | 2012-06-15 | 2w | 55d | 0d | AssemblyFirm | 80h |  |  |
| 209 | 3.13.4.10 | Firmware |  | 1w | 2013-04-01 | 2013-04-05 | 208FS+1w | 2012-06-25 | 2012-06-29 | 1w | 55d | 0d | Massimiliano Bitossi | 40h |  |  |
| 210 | 3.13.4.11 | Test |  | 1w | 2013-04-15 | 2013-04-19 | 209FS+1w | 2012-07-09 | 2012-07-13 | 1w | 55d |  | Massimiliano Bitossi | 40h |  |  |
| 211 | 3.9 | **Coil Drivers** |  | 485d | 2011-10-10 | 2013-08-16 |  | 2011-03-21 | 2012-11-09 | 430d | 55d |  |  | 1080h | 2,000 | 79,500 |
| 212 | 3.9.1 | Requirement Analysis |  | 2w | 2011-10-10 | 2011-10-21 | 198FS+2w | 2011-03-21 | 2011-04-01 | 2w | 110d | 0d | TBH_CtrlEng | 80h |  |  |
| 213 | 3.9.2 | Requirement Review | milestone | 0d | 2011-10-28 | 2011-10-28 | 212FS+1w | 2011-04-08 | 2011-04-08 | 0d | 110d | 0d |  |  |  |  |
| 214 | 3.9.3 | **Prototype** |  | 115d | 2011-11-07 | 2012-04-13 |  | 2011-04-18 | 2011-09-23 | 115d | 110d |  |  | 600h |  | 15,000 |
| 215 | 3.9.3.1 | Schematic Design |  | 2w | 2011-11-07 | 2011-11-18 | 213FS+1w | 2011-04-18 | 2011-04-29 | 2w | 110d | 0d | TBH_HwEng | 80h |  |  |
| 216 | 3.9.3.2 | Architectural Design Review | milestone | 0d | 2011-11-25 | 2011-11-25 | 215FS+1w | 2011-05-06 | 2011-05-06 | 0d | 110d | 0d |  |  |  |  |
| 217 | 3.9.3.3 | PCB Design |  | 4w | 2011-12-05 | 2011-12-30 | 216FS+1w | 2011-05-16 | 2011-06-10 | 4w | 110d | 0d | TBH_HwEng | 160h |  |  |
| 218 | 3.9.3.4 | Design Review | milestone | 0d | 2012-01-06 | 2012-01-06 | 217FS+1w | 2011-06-17 | 2011-06-17 | 0d | 110d | 0d |  |  |  |  |
| 219 | 3.9.3.5 | Components Purchase Req | milestone | 0d | 2012-01-13 | 2012-01-13 | 218FS+1w | 2011-06-24 | 2011-06-24 | 0d | 110d | 0d | Components |  |  | 12,000 |
| 220 | 3.9.3.6 | Components Procurement |  | 4w | 2012-01-16 | 2012-02-10 | 219 | 2011-06-27 | 2011-07-22 | 4w | 110d | 0d |  |  |  |  |
| 221 | 3.9.3.7 | Manufacturing Purchase Req. | milestone | 0d | 2012-01-13 | 2012-01-13 | 218FS+1w | 2011-06-24 | 2011-06-24 | 0d | 110d | 0d | PCBManufacturing |  |  | 2,000 |
| 222 | 3.9.3.8 | Manufacturing |  | 3w | 2012-01-23 | 2012-02-10 | 221FS+1w | 2011-07-04 | 2011-07-22 | 3w | 110d | 0d | PCBFirm | 120h |  |  |
| 223 | 3.9.3.9 | Assembly Purchase Req. | milestone | 0d | 2012-01-13 | 2012-01-13 | 218FS+1w | 2011-06-24 | 2011-06-24 | 0d | 130d | 20d | Assembly |  |  | 1,000 |
| 224 | 3.9.3.10 | Assembly |  | 3w | 2012-02-13 | 2012-03-02 | 220, 222, 223 | 2011-07-25 | 2011-08-12 | 3w | 110d | 0d | AssemblyFirm | 120h |  |  |
| 225 | 3.9.3.11 | Firmware |  | 2w | 2012-03-12 | 2012-03-23 | 224FS+1w | 2011-08-22 | 2011-09-02 | 2w | 110d | 0d | TBH_CtrlEng | 80h |  |  |
| 226 | 3.9.3.12 | Test |  | 1w | 2012-04-02 | 2012-04-06 | 225FS+1w | 2011-09-12 | 2011-09-16 | 1w | 110d | 0d | TBH_CtrlEng | 40h |  |  |
| 227 | 3.9.3.13 | Acceptance Test | milestone | 0d | 2012-04-13 | 2012-04-13 | 226FS+1w | 2011-09-23 | 2011-09-23 | 0d | 110d | 0d |  |  |  |  |

| ID | WBS | Task | Type | Duration | Start | Finish | Predecessors | Baseline start | Baseline finish | Baseline duration | Total slack | Free slack | Resources | Work | Cost | Baseline cost |
| --- | --- | --- | --- | --- | --- | --- | --- | --- | --- | --- | --- | --- | --- | --- | --- | --- |
| 228 | 3.9.4 | **Production** |  | 85d | 2013-04-22 | 2013-08-16 | 199 | 2012-07-16 | 2012-11-09 | 85d | 55d | 0d |  | 400h | 2,000 | 64,500 |
| 229 | 3.9.4.1 | Schematic Design |  | 1w | 2013-04-22 | 2013-04-26 | 227FS+1w | 2012-07-16 | 2012-07-20 | 1w | 55d | 0d | TBH_HwEng | 40h |  |  |
| 230 | 3.9.4.2 | PCB Design |  | 2w | 2013-05-06 | 2013-05-17 | 229FS+1w | 2012-07-30 | 2012-08-10 | 2w | 55d | 0d | TBH_HwEng | 80h |  |  |
| 231 | 3.9.4.3 | Final Design Review | milestone | 0d | 2013-05-24 | 2013-05-24 | 230FS+1w | 2012-08-17 | 2012-08-17 | 0d | 55d | 0d |  |  |  |  |
| 232 | 3.9.4.4 | Components Purchase Req | milestone | 0d | 2013-05-31 | 2013-05-31 | 231FS+1w | 2012-08-24 | 2012-08-24 | 0d | 65d | 0d | Components |  | 2,000 | 50,000 |
| 233 | 3.9.4.5 | Componentes Procurement |  | 2w | 2013-06-03 | 2013-06-14 | 232 | 2012-08-27 | 2012-09-07 | 2w | 65d | 10d |  |  |  |  |
| 234 | 3.9.4.6 | Manufacturing Purchase Req | milestone | 0d | 2013-05-31 | 2013-05-31 | 231FS+1w | 2012-08-24 | 2012-08-24 | 0d | 55d | 0d | PCBManufacturing |  |  | 8,500 |
| 235 | 3.9.4.7 | Manufacturing |  | 3w | 2013-06-10 | 2013-06-28 | 234FS+1w | 2012-09-03 | 2012-09-21 | 3w | 55d | 0d | PCBFirm | 120h |  |  |
| 236 | 3.9.4.8 | Assembly Purchase Req. | milestone | 0d | 2013-05-31 | 2013-05-31 | 231FS+1w | 2012-08-24 | 2012-08-24 | 0d | 80d | 25d | Assembly |  |  | 6,000 |
| 237 | 3.9.4.9 | Assembly |  | 2w | 2013-07-08 | 2013-07-19 | 233FS+1w, 235FS+1w, 236 | 2012-10-01 | 2012-10-12 | 2w | 55d | 0d | AssemblyFirm | 80h |  |  |
| 238 | 3.9.4.10 | Firmware |  | 1w | 2013-07-29 | 2013-08-02 | 237FS+1w | 2012-10-22 | 2012-10-26 | 1w | 55d | 0d | TBH_CtrlEng | 40h |  |  |
| 239 | 3.9.4.11 | Test |  | 1w | 2013-08-12 | 2013-08-16 | 238FS+1w | 2012-11-05 | 2012-11-09 | 1w | 55d |  | TBH_CtrlEng | 40h |  |  |
| 240 | 3.10 | **F7 Actuators/Sensors** |  | 425d | 2012-04-30 | 2013-12-13 |  | 2011-10-10 | 2013-03-08 | 370d | 55d |  |  | 1080h | -2,500 | 17,000 |
| 241 | 3.10.1 | Requirement Analysis |  | 2w | 2012-04-30 | 2012-05-11 | 227FS+2w | 2011-10-10 | 2011-10-21 | 2w | 110d | 0d | TBH_CtrlEng | 80h |  |  |
| 242 | 3.10.2 | Requirement Review | milestone | 0d | 2012-05-18 | 2012-05-18 | 241FS+1w | 2011-10-28 | 2011-10-28 | 0d | 110d | 0d |  |  |  |  |
| 243 | 3.10.3 | **Prototype** |  | 115d | 2012-05-28 | 2012-11-02 |  | 2011-11-07 | 2012-04-13 | 115d | 110d |  |  | 600h | -500 | 5,000 |
| 244 | 3.10.3.1 | Schematic Design |  | 2w | 2012-05-28 | 2012-06-08 | 242FS+1w | 2011-11-07 | 2011-11-18 | 2w | 110d | 0d | TBH_HwEng | 80h |  |  |
| 245 | 3.10.3.2 | Architectural Design Review | milestone | 0d | 2012-06-15 | 2012-06-15 | 244FS+1w | 2011-11-25 | 2011-11-25 | 0d | 110d | 0d |  |  |  |  |
| 246 | 3.10.3.3 | PCB Design |  | 4w | 2012-06-25 | 2012-07-20 | 245FS+1w | 2011-12-05 | 2011-12-30 | 4w | 110d | 0d | TBH_HwEng | 160h |  |  |
| 247 | 3.10.3.4 | Design Review | milestone | 0d | 2012-07-27 | 2012-07-27 | 246FS+1w | 2012-01-06 | 2012-01-06 | 0d | 110d | 0d |  |  |  |  |
| 248 | 3.10.3.5 | Components Purchase Req | milestone | 0d | 2012-08-03 | 2012-08-03 | 247FS+1w | 2012-01-13 | 2012-01-13 | 0d | 110d | 0d | Components |  | -500 | 2,000 |
| 249 | 3.10.3.6 | Components Procurement |  | 4w | 2012-08-06 | 2012-08-31 | 248 | 2012-01-16 | 2012-02-10 | 4w | 110d | 0d |  |  |  |  |
| 250 | 3.10.3.7 | Manufacturing Purchase Req. | milestone | 0d | 2012-08-03 | 2012-08-03 | 247FS+1w | 2012-01-13 | 2012-01-13 | 0d | 110d | 0d | PCBManufacturing |  |  | 2,000 |
| 251 | 3.10.3.8 | Manufacturing |  | 3w | 2012-08-13 | 2012-08-31 | 250FS+1w | 2012-01-23 | 2012-02-10 | 3w | 110d | 0d | PCBFirm | 120h |  |  |
| 252 | 3.10.3.9 | Assembly Purchase Req. | milestone | 0d | 2012-08-03 | 2012-08-03 | 247FS+1w | 2012-01-13 | 2012-01-13 | 0d | 130d | 20d | Assembly |  |  | 1,000 |
| 253 | 3.10.3.10 | Assembly |  | 3w | 2012-09-03 | 2012-09-21 | 249, 251, 252 | 2012-02-13 | 2012-03-02 | 3w | 110d | 0d | AssemblyFirm | 120h |  |  |
| 254 | 3.10.3.11 | Firmware |  | 2w | 2012-10-01 | 2012-10-12 | 253FS+1w | 2012-03-12 | 2012-03-23 | 2w | 110d | 0d | TBH_CtrlEng | 80h |  |  |
| 255 | 3.10.3.12 | Test |  | 1w | 2012-10-22 | 2012-10-26 | 254FS+1w | 2012-04-02 | 2012-04-06 | 1w | 110d | 0d | TBH_CtrlEng | 40h |  |  |
| 256 | 3.10.3.13 | Acceptance Test | milestone | 0d | 2012-11-02 | 2012-11-02 | 255FS+1w | 2012-04-13 | 2012-04-13 | 0d | 110d | 0d |  |  |  |  |

| ID | WBS | Task | Type | Duration | Start | Finish | Predecessors | Baseline start | Baseline finish | Baseline duration | Total slack | Free slack | Resources | Work | Cost | Baseline cost |
| --- | --- | --- | --- | --- | --- | --- | --- | --- | --- | --- | --- | --- | --- | --- | --- | --- |
| 257 | 3.10.4 | **Production** |  | 85d | 2013-08-19 | 2013-12-13 | 228 | 2012-11-12 | 2013-03-08 | 85d | 55d |  |  | 400h | -2,000 | 12,000 |
| 258 | 3.10.4.1 | Schematic Design |  | 1w | 2013-08-19 | 2013-08-23 | 256FS+1w | 2012-11-12 | 2012-11-16 | 1w | 55d | 0d | TBH_HwEng | 40h |  |  |
| 259 | 3.10.4.2 | PCB Design |  | 2w | 2013-09-02 | 2013-09-13 | 258FS+1w | 2012-11-26 | 2012-12-07 | 2w | 55d | 0d | TBH_HwEng | 80h |  |  |
| 260 | 3.10.4.3 | Final Design Review | milestone | 0d | 2013-09-20 | 2013-09-20 | 259FS+1w | 2012-12-14 | 2012-12-14 | 0d | 55d | 0d |  |  |  |  |
| 261 | 3.10.4.4 | Components Purchase Req | milestone | 0d | 2013-09-27 | 2013-09-27 | 260FS+1w | 2012-12-21 | 2012-12-21 | 0d | 65d | 0d | Components |  | -2,000 | 8,000 |
| 262 | 3.10.4.5 | Componentes Procurement |  | 2w | 2013-09-30 | 2013-10-11 | 261 | 2012-12-24 | 2013-01-04 | 2w | 65d | 10d |  |  |  |  |
| 263 | 3.10.4.6 | Manufacturing Purchase Req | milestone | 0d | 2013-09-27 | 2013-09-27 | 260FS+1w | 2012-12-21 | 2012-12-21 | 0d | 55d | 0d | PCBManufacturing |  |  | 2,500 |
| 264 | 3.10.4.7 | Manufacturing |  | 3w | 2013-10-07 | 2013-10-25 | 263FS+1w | 2012-12-31 | 2013-01-18 | 3w | 55d | 0d | PCBFirm | 120h |  |  |
| 265 | 3.10.4.8 | Assembly Purchase Req. | milestone | 0d | 2013-09-27 | 2013-09-27 | 260FS+1w | 2012-12-21 | 2012-12-21 | 0d | 80d | 25d | Assembly |  |  | 1,500 |
| 266 | 3.10.4.9 | Assembly |  | 2w | 2013-11-04 | 2013-11-15 | 262FS+1w, 264FS+1w, 265 | 2013-01-28 | 2013-02-08 | 2w | 55d | 0d | AssemblyFirm | 80h |  |  |
| 267 | 3.10.4.10 | Firmware |  | 1w | 2013-11-25 | 2013-11-29 | 266FS+1w | 2013-02-18 | 2013-02-22 | 1w | 55d | 0d | TBH_CtrlEng | 40h |  |  |
| 268 | 3.10.4.11 | Test |  | 1w | 2013-12-09 | 2013-12-13 | 267FS+1w | 2013-03-04 | 2013-03-08 | 1w | 55d |  | TBH_CtrlEng | 40h |  |  |
| 269 | 3.11 | **Piezo Drivers** |  | 280d | 2012-11-19 | 2013-12-13 |  | 2012-04-30 | 2013-03-08 | 225d | 55d |  |  | 1080h | 3,500 | 23,500 |
| 270 | 3.11.1 | Requirement Analysis |  | 2w | 2012-11-19 | 2012-11-30 | 256FS+2w | 2012-04-30 | 2012-05-11 | 2w | 110d | 0d | TBH_CtrlEng | 80h |  |  |
| 271 | 3.11.2 | Requirement Review | milestone | 0d | 2012-12-07 | 2012-12-07 | 270FS+1w | 2012-05-18 | 2012-05-18 | 0d | 110d | 0d |  |  |  |  |
| 272 | 3.11.3 | **Prototype** |  | 115d | 2012-12-17 | 2013-05-24 |  | 2012-05-28 | 2012-11-02 | 115d | 110d |  |  | 600h |  | 6,000 |
| 273 | 3.11.3.1 | Schematic Design |  | 2w | 2012-12-17 | 2012-12-28 | 271FS+1w | 2012-05-28 | 2012-06-08 | 2w | 110d | 0d | Alberto Gennai | 80h |  |  |
| 274 | 3.11.3.2 | Architectural Design Review | milestone | 0d | 2013-01-04 | 2013-01-04 | 273FS+1w | 2012-06-15 | 2012-06-15 | 0d | 110d | 0d |  |  |  |  |
| 275 | 3.11.3.3 | PCB Design |  | 4w | 2013-01-14 | 2013-02-08 | 274FS+1w | 2012-06-25 | 2012-07-20 | 4w | 110d | 0d | TBH_HwEng | 160h |  |  |
| 276 | 3.11.3.4 | Design Review | milestone | 0d | 2013-02-15 | 2013-02-15 | 275FS+1w | 2012-07-27 | 2012-07-27 | 0d | 110d | 0d |  |  |  |  |
| 277 | 3.11.3.5 | Components Purchase Req | milestone | 0d | 2013-02-22 | 2013-02-22 | 276FS+1w | 2012-08-03 | 2012-08-03 | 0d | 110d | 0d | Components |  |  | 3,000 |
| 278 | 3.11.3.6 | Components Procurement |  | 4w | 2013-02-25 | 2013-03-22 | 277 | 2012-08-06 | 2012-08-31 | 4w | 110d | 0d |  |  |  |  |
| 279 | 3.11.3.7 | Manufacturing Purchase Req. | milestone | 0d | 2013-02-22 | 2013-02-22 | 276FS+1w | 2012-08-03 | 2012-08-03 | 0d | 110d | 0d | PCBManufacturing |  |  | 2,000 |
| 280 | 3.11.3.8 | Manufacturing |  | 3w | 2013-03-04 | 2013-03-22 | 279FS+1w | 2012-08-13 | 2012-08-31 | 3w | 110d | 0d | PCBFirm | 120h |  |  |
| 281 | 3.11.3.9 | Assembly Purchase Req. | milestone | 0d | 2013-02-22 | 2013-02-22 | 276FS+1w | 2012-08-03 | 2012-08-03 | 0d | 130d | 20d | Assembly |  |  | 1,000 |
| 282 | 3.11.3.10 | Assembly |  | 3w | 2013-03-25 | 2013-04-12 | 278, 280, 281 | 2012-09-03 | 2012-09-21 | 3w | 110d | 0d | AssemblyFirm | 120h |  |  |
| 283 | 3.11.3.11 | Firmware |  | 2w | 2013-04-22 | 2013-05-03 | 282FS+1w | 2012-10-01 | 2012-10-12 | 2w | 110d | 0d | TBH_CtrlEng | 80h |  |  |
| 284 | 3.11.3.12 | Test |  | 1w | 2013-05-13 | 2013-05-17 | 283FS+1w | 2012-10-22 | 2012-10-26 | 1w | 110d | 0d | TBH_CtrlEng | 40h |  |  |
| 285 | 3.11.3.13 | Acceptance Test | milestone | 0d | 2013-05-24 | 2013-05-24 | 284FS+1w | 2012-11-02 | 2012-11-02 | 0d | 110d | 55d |  |  |  |  |

| ID | WBS | Task | Type | Duration | Start | Finish | Predecessors | Baseline start | Baseline finish | Baseline duration | Total slack | Free slack | Constraint | Resources | Work | Cost | Baseline cost |
| --- | --- | --- | --- | --- | --- | --- | --- | --- | --- | --- | --- | --- | --- | --- | --- | --- | --- |
| 286 | 3.11.4 | **Production** |  | 85d | 2013-08-19 | 2013-12-13 | 228 | 2012-11-12 | 2013-03-08 | 85d | 55d |  |  |  | 400h | 3,500 | 17,500 |
| 287 | 3.11.4.1 | Schematic Design |  | 1w | 2013-08-19 | 2013-08-23 | 285FS+1w | 2012-11-12 | 2012-11-16 | 1w | 55d | 0d |  | TBH_HwEng | 40h |  |  |
| 288 | 3.11.4.2 | PCB Design |  | 2w | 2013-09-02 | 2013-09-13 | 287FS+1w | 2012-11-26 | 2012-12-07 | 2w | 55d | 0d |  | TBH_HwEng | 80h |  |  |
| 289 | 3.11.4.3 | Final Design Review | milestone | 0d | 2013-09-20 | 2013-09-20 | 288FS+1w | 2012-12-14 | 2012-12-14 | 0d | 55d | 0d |  |  |  |  |  |
| 290 | 3.11.4.4 | Components Purchase Req | milestone | 0d | 2013-09-27 | 2013-09-27 | 289FS+1w | 2012-12-21 | 2012-12-21 | 0d | 65d | 0d |  | Components |  | 3,000 | 13,000 |
| 291 | 3.11.4.5 | Componentes Procurement |  | 2w | 2013-09-30 | 2013-10-11 | 290 | 2012-12-24 | 2013-01-04 | 2w | 65d | 10d |  |  |  |  |  |
| 292 | 3.11.4.6 | Manufacturing Purchase Req | milestone | 0d | 2013-09-27 | 2013-09-27 | 289FS+1w | 2012-12-21 | 2012-12-21 | 0d | 55d | 0d |  | PCBManufacturing |  | 500 | 3,000 |
| 293 | 3.11.4.7 | Manufacturing |  | 3w | 2013-10-07 | 2013-10-25 | 292FS+1w | 2012-12-31 | 2013-01-18 | 3w | 55d | 0d |  | PCBFirm | 120h |  |  |
| 294 | 3.11.4.8 | Assembly Purchase Req. | milestone | 0d | 2013-09-27 | 2013-09-27 | 289FS+1w | 2012-12-21 | 2012-12-21 | 0d | 80d | 25d |  | Assembly |  |  | 1,500 |
| 295 | 3.11.4.9 | Assembly |  | 2w | 2013-11-04 | 2013-11-15 | 291FS+1w, 293FS+1w, 294 | 2013-01-28 | 2013-02-08 | 2w | 55d | 0d |  | AssemblyFirm | 80h |  |  |
| 296 | 3.11.4.10 | Firmware |  | 1w | 2013-11-25 | 2013-11-29 | 295FS+1w | 2013-02-18 | 2013-02-22 | 1w | 55d | 0d |  | TBH_CtrlEng | 40h |  |  |
| 297 | 3.11.4.11 | Test |  | 1w | 2013-12-09 | 2013-12-13 | 296FS+1w | 2013-03-04 | 2013-03-08 | 1w | 55d |  |  | TBH_CtrlEng | 40h |  |  |
| 298 | 3.17 | Laboratory Tools |  | 36mo? | 2010-03-01 | 2012-11-30 |  | 2010-03-01 | 2012-11-30 | 36mo? | 325d |  |  | Generic [0.3%] |  | 150,000 | 150,000 |
| 299 | 3.17 | Suspension Control Software |  | 36mo? | 2010-03-01 | 2012-11-30 |  | 2010-03-01 | 2012-11-30 | 36mo? | 325d |  |  | Giulio Ballardin | 5760h |  |  |
| 300 | 3.18 | Assembly & Integration |  | 1mo? | 2011-06-01 | 2011-06-28 |  | 2011-06-01 | 2011-06-28 | 1mo? | 558d | 0d | start no earlier than 2011-06-01 | Generic [2.3%] |  | 36,000 | 36,000 |
| 301 | 3.19 | Commissioning |  | 6mo? | 2011-07-27 | 2012-01-10 | 300FS+1mo | 2011-07-27 | 2012-01-10 | 6mo? | 558d |  |  |  |  |  |  |
| 302 | NA | AdV Assembly Start | milestone | 0d | 2011-06-01 | 2011-06-01 |  | 2011-06-01 | 2011-06-01 | 0d | 718d |  | start no earlier than 2011-06-01 |  |  |  |  |
| 303 | NA | Adv Commissioning Start | milestone | 0d | 2014-03-03 | 2014-03-03 |  | 2014-03-03 | 2014-03-03 | 0d | 0d |  | start no earlier than 2014-03-03 |  |  |  |  |

Notes:
- 300: Includes cabling
